# Zeitplan_A07535_00

Schedule from MS Project, 2026-07-31 to 2028-11-15, A marks actual dates.
Die Autobahn GmbH des Bundes

## Calendars

- Standard: Mon-Fri 08:00-12:00, 13:00-17:00; Sat-Sun off.

## Resources

| Resource |
| --- |
| Eugen Diner, Tobias Kraxenberg |
| Ester Schuppenhauer, Eugen Diner, Torsten Sentheim, Mareen Kubin |
| 4 |
| Mareen Kubin, Ariane Sievers |
| Mareen Kubin, Ariane Sievers, Wiebke Sekulla, Peter Kollig |
| Eugen Diner, Olaf Hoffmann |
| Eufen Diner, Esther Schuppenhauer, Tobias Kraxenberger, Marielle Dubuqc |
| Eugen Diner, Esther Schuppenhauer, Tobias Kraxenberger, Marielle Dubuqc |
| Esther Schuppenhauer |
| Tobias Kraxenberg |
| Marielle Dubucq |
| Eugen Diner |
| Mareen Kubin |
| Ariane Sievers |
| Wiebk Sekulla |
| Peter Kollig |
| Peter Bennewitz |
| Sven Ostermann |
| Olaf Hoffmann |
| Finn Gottschalk |
| Torsten Sentheim |
| Wiebke Sekulla |
| Vergabestelle |
| Bennewitz |

## Schedule

| ID | WBS | Task | Type | Duration | Start | Finish | Predecessors | Complete | Remaining | Total slack | Free slack | Constraint | Resources | Work | Actual work | Text1 |
| --- | --- | --- | --- | --- | --- | --- | --- | --- | --- | --- | --- | --- | --- | --- | --- | --- |
| 1 | 1 | **Vergabe Planungsleistung EU-weit** |  | 6d | 2026-07-31 A | 2026-08-07 |  | 9% | 5.46d |  |  |  |  | 552h | 60h |  |
| 2 | 1.1 | Vorbereitung LV's |  | 2.8w | 2026-07-31 A | 2026-08-19 |  | 54% | 1.3w | 47d | 0d | finish no earlier than 2026-08-19 | Bennewitz | 112h | 60h |  |
| 3 | 1.2 | Bearbeitung Vergabe |  | 2w | 2026-08-20 | 2026-09-02 | 2 |  |  | 47d | 0d |  | Vergabestelle | 80h |  |  |
| 4 | 1.3 | Veröffentlichung LV's |  | 30d | 2026-09-03 | 2026-10-14 | 3 |  |  | 47d | 0d |  | Vergabestelle | 240h |  |  |
| 5 | 1.4 | Wertung Angebote und Zuschlag |  | 3w | 2026-10-15 | 2026-11-04 | 4 |  |  | 47d | 0d |  | Bennewitz | 120h |  |  |
| 6 | 1.5 | Stillhaltefrist | manual | 10d | 2026-10-23 | 2026-11-05 | 5 |  |  |  |  |  |  |  |  |  |
| 7 | 1.6 | Puffer |  | 1w | 2026-08-03 | 2026-08-07 |  |  |  | 557d |  | finish no earlier than 2026-08-07 |  |  |  |  |
| 8 | 2 | **Planungsphase** |  | 530d? | 2026-11-05 | 2028-11-15 | 5 |  |  | 0d |  |  |  |  |  |  |
| 9 | 2.1 | Auftaktgespräch Planer | milestone | 1d | 2026-11-05 | 2026-11-05 | 5 |  |  | 47d | 0d |  |  |  |  |  |
| 10 | 2.2 | **Technische Planung** |  | 529d? | 2026-11-06 | 2028-11-15 | 9 |  |  | 0d |  |  |  |  |  |  |
| 11 | 2.2.1 | Entwurfsplanung |  | 6w | 2026-11-06 | 2026-12-17 |  |  |  | 499d |  |  |  |  |  |  |
| 12 | 2.2.2 | Genehmigungsplanung |  | 4w | 2027-01-11 | 2027-02-05 |  |  |  | 1d | 0d | start no earlier than 2027-01-11 |  |  |  |  |
| 13 | 2.2.3 | Ausführungsplanung |  | 8w | 2027-02-08 | 2027-04-02 | 12 |  |  | 1d | 0d |  |  |  |  |  |
| 14 | 2.2.4 | Vorbereitung d. Vergabe |  | 2w | 2027-04-05 | 2027-04-16 | 13 |  |  | 1d |  |  |  |  |  |  |
| 15 | 2.2.5 | Durchführung Vergabe Bauleistung |  | 6w | 2027-04-20 | 2027-05-31 | 14 |  |  | 0d |  | finish no earlier than 2027-05-31 |  |  |  | Nat. Vergabe nach VOB |
| 16 | 2.2.6 | Vertragsabschluss Bauleistungen | milestone | 1d? | 2027-06-01 | 2027-06-01 | 15 |  |  | 0d |  |  |  |  |  |  |
| 17 | 2.2.7 | Objektüberwachung |  | 16mo | 2027-07-15 | 2028-10-04 | 31 |  |  | 0d |  |  |  |  |  |  |
| 18 | 2.2.8 | Objektbetreuung |  | 6w | 2028-10-05 | 2028-11-15 | 17 |  |  | 0d |  |  |  |  |  |  |
| 19 | 2.3 | **Umweltplanung** |  | 130d? | 2026-11-06 | 2027-05-06 | 9 |  |  | 399d |  |  |  |  |  |  |
| 20 | 2.3.1 | Klären d. Aufgabenstellung |  | 2w | 2026-11-06 | 2026-11-19 | 9 |  |  | 399d | 0d |  |  |  |  |  |
| 21 | 2.3.2 | Ermitteln u. Bewerten d. Planungsgrundlagen |  | 20d | 2026-11-20 | 2026-12-17 | 20 |  |  | 399d | 0d |  |  |  |  |  |
| 22 | 2.3.3 | Erstellen vorläufige Fassung LPB |  | 20d | 2026-12-18 | 2027-01-14 | 21 |  |  | 399d | 0d |  |  |  |  |  |
| 23 | 2.3.4 | Artenschutzbeitrag erstellen |  | 20d | 2027-01-15 | 2027-02-11 | 22 |  |  | 399d | 0d |  |  |  |  |  |
| 24 | 2.3.5 | FFH Vorprüfung |  | 20d | 2027-02-12 | 2027-03-11 | 23 |  |  | 399d | 0d |  |  |  |  |  |
| 25 | 2.3.6 | FFH-Verträglichkeitsprüfung |  | 20d | 2027-03-12 | 2027-04-08 | 24 |  |  | 399d | 0d |  |  |  |  |  |
| 26 | 2.3.7 | Erbringung sonstige bes. Leistungen |  | 20d? | 2027-04-09 | 2027-05-06 | 25 |  |  | 399d |  |  |  |  |  |  |

| ID | WBS | Task | Type | Duration | Start | Finish | Predecessors | Complete | Remaining | Total slack | Free slack | Deadline | Text1 |
| --- | --- | --- | --- | --- | --- | --- | --- | --- | --- | --- | --- | --- | --- |
| 27 | 3 | **Bauphase** |  | 345d? | 2027-06-02 A | 2028-09-26 | 16 | 23% | 264.58d? | 36d |  |  |  |
| 28 | 3.1 | Auftaktgespräch | milestone | 1d? | 2027-06-02 | 2027-06-02 | 16 |  |  | 0d |  |  |  |
| 29 | 3.2 | Umweltbaubegleitung |  | 24w? | 2027-07-15 | 2027-12-29 | 31 |  |  | 230d |  |  |  |
| 30 | 3.3 | Freischneiden Baufeld | manual | 108d | 2027-10-01 A | 2028-02-29 | 28 | 93% | 8d |  |  | 2027-10-01 |  |
| 31 | 3.4 | Materialbestellung |  | 6w | 2027-06-03 | 2027-07-14 | 28 |  |  | 0d |  |  |  |
| 32 | 3.5 | Schachteinbau Abschnitt1 |  | 20d | 2027-07-15 | 2027-08-11 | 31 |  |  | 330d |  |  | Wenn mit kleinem Rückschnitt möglich. |
| 33 | 3.6 | Kabelanlagenbau Abschnitt2 |  | 20w | 2028-03-01 | 2028-07-18 | 30 |  |  | 36d | 0d |  |  |
| 34 | 3.7 | Kabeleinzug |  | 10w | 2028-07-19 | 2028-09-26 | 33 |  |  | 36d |  |  |  |
